# Projekt_jo_02_03

How a schedule from MS Project changed from version to version. A marks actual dates.

## Version 1 (data date 2008-08-29, saved 2008-04-22, file Projekt_03_alap_2007.mpp)

| ID | Task | Duration | Start | Finish | Predecessors | Total float |
| --- | --- | --- | --- | --- | --- | --- |
| 1 | előkészítés | 16.5d? | 2008-08-08 | 2008-09-01 |  | 4d |
| 2 | igények felmérése | 1d? | 2008-08-08 | 2008-08-08 |  | 19.5d |
| 3 | igények kiértékelése | 1d? | 2008-08-08 | 2008-08-08 |  | 19.5d |
| 4 | A számítógépes munkavégzés analizálása | 3d | 2008-08-08 | 2008-08-12 |  | 1d |
| 5 | Az operációsrendszer és a felhasználói programok tesztelése | 4d | 2008-08-08 | 2008-08-13 |  | 0d |
| 6 | Legális hackelés | 5d | 2008-08-14 | 2008-08-20 | 5, 4 | 0d |
| 7 | - | 2d | 2008-08-21 | 2008-08-22 | 6 | 0d |
| 8 | Adatok kiértékelése | 3d | 2008-08-20 | 2008-08-22 | 6SS+2d, 7FF | 0d |
| 9 | megoldási lehetőségek kidolgozása | 3d | 2008-08-25 | 2008-08-27 | 8 | 0d |
| 10 | javaslatok dokumentum kész | 0d | 2008-08-27 | 2008-08-27 | 9 | 6.5d |
| 11 | megoldási lehetőségek ismertetése | 4h | 2008-08-28 | 2008-08-28 | 9 | 0d |
| 12 | döntés a megvalósítandó lehetőségről | 0d | 2008-08-28 | 2008-08-28 | 11 | 0d |
| 13 | részletes terv kidolgozása | 6d | 2008-08-28 | 2008-09-05 | 12 | 0d |
| 14 | terv elfogadtatása | 0d | 2008-09-05 | 2008-09-05 | 13 | 0d |

## Version 2 (data date 2008-10-31, saved 2010-05-19, file Projekt_03_alap_2007_resz.mpp)

Last finish 2008-09-05 → 2008-12-01 (+87d). Complete tasks 0 → 1.

Added:

| ID | Task | Duration | Start | Finish | Predecessors | Resources |
| --- | --- | --- | --- | --- | --- | --- |
| 2 | A vállalat hardverkiépítettségének vizsgálata | 4d | 2008-10-15 A | 2008-10-21 A |  | Á hálózatépítő 2; Á műszaki informatikus 3 |
| 4 | igények felmérése befejezés | 1d? | 2008-10-28 | 2008-10-29 | 3FF |  |
| 8 | Legális hackelés engedélyezése | 0d | 2008-10-15 | 2008-11-07 |  |  |

Changed:

| ID | Task | Start | Finish | Duration | Complete | Total float | Predecessors | Other |
| --- | --- | --- | --- | --- | --- | --- | --- | --- |
| 1 | **előkészítés** | 2008-08-08 → 2008-10-15 A (+68d) | 2008-09-01 → 2008-12-01 (+91d) | 16.5d? → 33.5d? | 0% → 9% | 4d → 0d |  | constraint none → as late as possible; baseline start none → 2008-10-15; baseline finish none → 2008-12-01 |
| 3 | igények felmérése | 2008-08-08 → 2008-10-15 (+68d) | 2008-08-08 → 2008-10-29 (+82d) | 1d? → 10d |  | 19.5d → 0d | none → 2SS | constraint none → start no later than 2008-10-17; resources none → Á adminisztrátor 1; Á adminisztrátor 2; Á adminisztrátor 3; Téglás Csaba; baseline start none → 2008-10-15; baseline finish none → 2008-10-29 |
| 5 | igények kiértékelése | 2008-08-08 → 2008-10-28 (+81d) | 2008-08-08 → 2008-11-03 (+87d) | 1d? → 4d |  | 19.5d → 0d | none → 3SS+4d, 4FF+3d | resources none → Á adminisztrátor 4; Téglás Csaba; Á műszaki informatikus 2; baseline start none → 2008-10-28; baseline finish none → 2008-11-03 |
| 6 | A számítógépes munkavégzés analizálása | 2008-08-08 → 2008-11-03 (+87d) | 2008-08-12 → 2008-11-06 (+86d) |  |  |  | none → 5 | resources none → Téglás Csaba; baseline start none → 2008-11-03; baseline finish none → 2008-11-06 |
| 7 | Az operációsrendszer és a felhasználói programok tesztelése | 2008-08-08 → 2008-11-03 (+87d) | 2008-08-13 → 2008-11-07 (+86d) |  |  |  | none → 5 | resources none → Á műszaki informatikus 2; baseline start none → 2008-11-03; baseline finish none → 2008-11-07 |
| 9 | Legális hackelés | 2008-08-14 → 2008-11-07 (+85d) | 2008-08-20 → 2008-11-14 (+86d) |  |  |  | 7, 6 → 7, 6, 8 | resources Á programozó 1; Á programozó 2; Á műszaki informatikus 1 → Á programozó 1; Á programozó 2; Téglás Csaba; Szoftverköltségek [180000 eFt]; baseline start none → 2008-11-07; baseline finish none → 2008-11-14 |
| 10 | - | 2008-08-21 → 2008-11-14 (+85d) | 2008-08-22 → 2008-11-18 (+88d) |  |  |  |  | baseline start none → 2008-11-14; baseline finish none → 2008-11-18 |
| 11 | Adatok kiértékelése | 2008-08-20 → 2008-11-13 (+85d) | 2008-08-22 → 2008-11-18 (+88d) |  |  |  |  | baseline start none → 2008-11-13; baseline finish none → 2008-11-18 |
| 12 | megoldási lehetőségek kidolgozása | 2008-08-25 → 2008-11-18 (+85d) | 2008-08-27 → 2008-11-21 (+86d) |  |  |  |  | resources Á adminisztrátor 1; Á hálózatépítő 1; Á műszaki informatikus 1; Á programozó 1 → Á adminisztrátor 1; Á hálózatépítő 1; Téglás Csaba; Á programozó 1; baseline start none → 2008-11-18; baseline finish none → 2008-11-21 |
| 13 | javaslatok dokumentum kész | 2008-08-27 → 2008-11-21 (+86d) | 2008-08-27 → 2008-12-01 (+96d) |  |  | 6.5d → 0d |  | baseline start none → 2008-11-21; baseline finish none → 2008-12-01 |
| 14 | megoldási lehetőségek ismertetése | 2008-08-28 → 2008-11-21 (+85d) | 2008-08-28 → 2008-11-21 (+85d) |  |  |  |  | baseline start none → 2008-11-21; baseline finish none → 2008-11-21 |
| 15 | döntés a megvalósítandó lehetőségről | 2008-08-28 → 2008-11-21 (+85d) | 2008-08-28 → 2008-11-24 (+88d) |  |  |  |  | baseline start none → 2008-11-21; baseline finish none → 2008-11-24 |
| 16 | részletes terv kidolgozása | 2008-08-28 → 2008-11-24 (+88d) | 2008-09-05 → 2008-12-01 (+87d) |  |  |  |  | baseline start none → 2008-11-24; baseline finish none → 2008-12-01 |
| 17 | terv elfogadtatása | 2008-09-05 → 2008-12-01 (+87d) | 2008-09-05 → 2008-12-01 (+87d) |  |  |  |  | baseline start none → 2008-12-01; baseline finish none → 2008-12-01 |
